# Planning

Schedule from MS Project, 2002-01-07 to 2002-03-19.
CERN

## Calendars

- Standard: Mon-Fri 08:00-12:00, 13:00-17:00; Sat-Sun off.

## Resources

| Resource |
| --- |
| ps/po reg1 |
| PO/Reg1 |
| ST/IE |
| ST/EL |
| PO/SC |
| PO/REG2 |
| PO/REG |
| PO/REG3 |
| PS/PO PS/CO |
| ST/HM |
| Ent. Ext. |
| PO/Reg1Aménagement des racks |
| Aménagement des racks |
| J.P-L./G.S. |
| P0/Reg2 |
| P0/Reg2P0/Reg2 |
| P |
| PS/Reg3 |

## Schedule

| ID | WBS | Task | Duration | Start | Finish | Predecessors | Total slack | Free slack | Resources | Work |
| --- | --- | --- | --- | --- | --- | --- | --- | --- | --- | --- |
| 2 | 1 | **Projet de rénovation des contrôles Isolde (Alimentations)** | 52d | 2002-01-07 08:00 | 2002-03-19 17:00 |  | 0d |  |  | 1332h |
| 4 | 1.1 | **Alimentations "BEAMLINES"** | 47.5d | 2002-01-07 08:00 | 2002-03-13 12:00 |  | 4.5d |  |  | 572h |
| 5 | 1.1.1 | Décâblage des câbles lemo | 1.5d | 2002-01-07 08:00 | 2002-01-08 12:00 |  | 4.5d | 0d | PO/Reg1 | 12h |
| 6 | 1.1.2 | Décâblage des câbles 220v | 0.5d | 2002-01-08 13:00 | 2002-01-08 17:00 | 5 | 4.5d | 0d | PO/Reg1 | 4h |
| 7 | 1.1.3 | Décâblage des câbles HT Mutilpôles | 0.5d | 2002-01-09 08:00 | 2002-01-09 12:00 | 6 | 4.5d | 0d | PO/Reg1 | 4h |
| 8 | 1.1.4 | Retrait des interfaces de contrôle | 0.5d | 2002-01-09 13:00 | 2002-01-09 17:00 | 7 | 4.5d | 0d | PO/Reg1 | 4h |
| 9 | 1.1.5 | Réaménagement des racks | 4d | 2002-01-10 08:00 | 2002-01-15 17:00 | 8 | 4.5d | 0d | PO/Reg1 | 32h |
| 10 | 1.1.6 | Remplacement des patchs panels | 4d | 2002-01-16 08:00 | 2002-01-21 17:00 | 9 | 4.5d | 0d | PO/Reg1 | 32h |
| 11 | 1.1.7 | Installation des châssis de distribution 220v | 1d | 2002-01-22 08:00 | 2002-01-22 17:00 | 10 | 4.5d | 0d | PO/Reg1 | 8h |
| 12 | 1.1.8 | Installation des châssis de distribution 24v | 0.5d | 2002-01-23 08:00 | 2002-01-23 12:00 | 11 | 4.5d | 0d | PO/Reg1 | 4h |
| 13 | 1.1.9 | Installation des châssis interface contrôle | 5d | 2002-01-23 13:00 | 2002-01-30 12:00 | 12 | 4.5d | 0d | PO/Reg1 | 40h |
| 14 | 1.1.10 | Installation d'un disjoncteur différentiel | 1d | 2002-01-30 13:00 | 2002-01-31 12:00 | 13 | 24.5d | 0d | ST/EL | 8h |
| 15 | 1.1.11 | Câblage HT interne des Multipôles | 2d | 2002-01-31 13:00 | 2002-02-04 12:00 | 14 | 24.5d | 0d | PO/Reg1 | 16h |
| 16 | 1.1.12 | Câblage HT externe des Multipôles | 3d | 2002-02-04 13:00 | 2002-02-07 12:00 | 15 | 24.5d | 0d | ST/EL | 24h |
| 17 | 1.1.13 | Câblage distribution 400v | 3d | 2002-02-07 13:00 | 2002-02-12 12:00 | 16 | 24.5d | 0d | ST/EL | 24h |
| 18 | 1.1.14 | Câblage piussance 24v | 1d | 2002-02-12 13:00 | 2002-02-13 12:00 | 17 | 24.5d |  | ST/EL | 8h |
| 19 | 1.1.15 | Câblage distribution 220v | 5d | 2002-01-30 13:00 | 2002-02-06 12:00 | 13 | 4.5d | 0d | PO/Reg1 | 40h |
| 20 | 1.1.16 | Câblage contrôle et interlocks | 10d | 2002-02-06 13:00 | 2002-02-20 12:00 | 19 | 4.5d | 0d | PO/Reg1 | 80h |
| 21 | 1.1.17 | Tests | 15d | 2002-02-20 13:00 | 2002-03-13 12:00 | 20 | 4.5d |  | PS/PO PS/CO | 120h |
| 23 | 1.1.18 | **Transformateurs HT** | 13d | 2002-02-20 13:00 | 2002-03-11 12:00 |  | 6.5d |  |  | 112h |
| 24 | 1.1.18.1 | Décâblage contrôle | 0.5d | 2002-02-20 13:00 | 2002-02-20 17:00 | 20 | 6.5d | 0d | PO/Reg1 | 4h |
| 25 | 1.1.18.2 | Décâblage 230V | 0.5d | 2002-02-21 08:00 | 2002-02-21 12:00 | 24 | 6.5d | 0d | PO/Reg1 | 4h |
| 26 | 1.1.18.3 | Décâblage des liaisons -> châssis de sécurité | 0.5d | 2002-02-21 13:00 | 2002-02-21 17:00 | 25 | 6.5d | 0d | PO/Reg1 | 4h |
| 27 | 1.1.18.4 | Démontage des anciens châssis de commande | 0.5d | 2002-02-22 08:00 | 2002-02-22 12:00 | 26 | 6.5d | 0d | PO/Reg1 | 4h |
| 28 | 1.1.18.5 | Installation du châssis de distribution 230V | 0.5d | 2002-02-22 13:00 | 2002-02-22 17:00 | 27 | 6.5d | 0d | PO/Reg1 | 4h |
| 29 | 1.1.18.6 | Installation des châssis de commande | 0.5d | 2002-02-25 08:00 | 2002-02-25 12:00 | 28 | 6.5d | 0d | PO/Reg1 | 4h |
| 30 | 1.1.18.7 | Installation des châssis contrôle | 0.5d | 2002-02-25 13:00 | 2002-02-25 17:00 | 29 | 6.5d | 0d | PO/Reg1 | 4h |
| 31 | 1.1.18.8 | Installation du patch panel vide | 0.5d | 2002-02-26 08:00 | 2002-02-26 12:00 | 30 | 6.5d | 0d | PO/Reg1 | 4h |
| 32 | 1.1.18.9 | Câblage 220V | 1d | 2002-02-26 13:00 | 2002-02-27 12:00 | 31 | 6.5d | 0d | PO/Reg1 | 8h |
| 33 | 1.1.18.10 | Câblage 400V | 1d | 2002-02-27 13:00 | 2002-02-28 12:00 | 32 | 6.5d | 0d | ST/EL | 8h |
| 34 | 1.1.18.11 | Câblage contrôle | 1d | 2002-02-28 13:00 | 2002-03-01 12:00 | 33 | 6.5d | 0d | ST/EL | 8h |
| 35 | 1.1.18.12 | Câblage interlocks | 3d | 2002-03-01 13:00 | 2002-03-06 12:00 | 34 | 6.5d | 0d | ST/EL | 24h |
| 36 | 1.1.18.13 | Tests | 3d | 2002-03-06 13:00 | 2002-03-11 12:00 | 35 | 6.5d |  | PS/PO PS/CO | 24h |
| 37 | 1.1.18.14 | Changement du bucholz GPS | 1d | 2002-02-21 08:00 | 2002-02-21 17:00 | 24 | 18d |  | Ent. Ext. | 8h |

| ID | WBS | Task | Duration | Start | Finish | Predecessors | Total slack | Free slack | Resources | Work |
| --- | --- | --- | --- | --- | --- | --- | --- | --- | --- | --- |
| 39 | 1.2 | **Alimentations zône HT GPS** | 38d | 2002-01-07 08:00 | 2002-02-27 17:00 |  | 0d |  |  | 328h |
| 40 | 1.2.1 | Démontage des alimentations 500 et 1000A | 6d | 2002-01-07 08:00 | 2002-01-14 17:00 |  | 0d |  | P0/Reg2 | 48h |
| 41 | 1.2.2 | Transport des alimentations 500 et 1000A | 1d | 2002-01-15 08:00 | 2002-01-15 17:00 | 40 | 0d |  | ST/HM | 8h |
| 42 | 1.2.3 | Décâblage du reseau 400V | 0.5d | 2002-01-16 08:00 | 2002-01-16 12:00 | 41 | 0d |  | P0/Reg2 | 4h |
| 43 | 1.2.4 | Décâblage des cables contrôle | 0.5d | 2002-01-16 13:00 | 2002-01-16 17:00 | 42 | 0d |  | P0/Reg2 | 4h |
| 44 | 1.2.5 | Démontage des châssis contrôle | 0.5d | 2002-01-17 08:00 | 2002-01-17 12:00 | 43 | 0d |  | P0/Reg2 | 4h |
| 45 | 1.2.6 | Aménagement des racks | 2d | 2002-01-17 13:00 | 2002-01-21 12:00 | 44 | 0d |  | P0/Reg2 | 16h |
| 46 | 1.2.7 | Modification des alimentations Fug | 3d | 2002-01-17 13:00 | 2002-01-22 12:00 | 44 | 40.5d |  | J.P-L./G.S. | 24h |
| 47 | 1.2.8 | Installation des châssis de distribution 400v | 0.5d | 2002-01-21 13:00 | 2002-01-21 17:00 | 45 | 0d |  | PO/REG2 | 4h |
| 48 | 1.2.9 | Installation des alimentations 500 et 1000A | 5d | 2002-01-22 08:00 | 2002-01-28 17:00 | 47 | 0d |  | P0/Reg2 | 40h |
| 49 | 1.2.10 | Installation des châssis contrôle | 1d | 2002-01-29 08:00 | 2002-01-29 17:00 | 48 | 0d |  | P0/Reg2 | 8h |
| 50 | 1.2.11 | Câblage puissance | 2d | 2002-01-30 08:00 | 2002-01-31 17:00 | 49 | 0d |  | P0/Reg2 | 16h |
| 51 | 1.2.12 | Câblage 220v | 2d | 2002-02-01 08:00 | 2002-02-04 17:00 | 50 | 0d |  | P0/Reg2 | 16h |
| 52 | 1.2.13 | Câblage 400v | 2d | 2002-02-05 08:00 | 2002-02-06 17:00 | 51 | 14d | 0d | ST/EL | 16h |
| 53 | 1.2.14 | Câblage contrôle et interlocks | 5d | 2002-02-07 08:00 | 2002-02-13 17:00 | 52 | 14d | 0d | ST/EL | 40h |
| 54 | 1.2.15 | Tests | 10d | 2002-02-14 08:00 | 2002-02-27 17:00 | 53 | 14d |  | PS/PO PS/CO | 80h |
| 56 | 1.3 | **Alimentations zône HT HRS** | 31d | 2002-02-05 08:00 | 2002-03-19 17:00 | 51 | 0d |  |  | 328h |
| 57 | 1.3.1 | Démontage des alimentations 500 et 1000A | 6d | 2002-02-05 08:00 | 2002-02-12 17:00 | 51 | 0d |  | P0/Reg2 | 48h |
| 58 | 1.3.2 | Transport des alimentations 500 et 1000A | 1d | 2002-02-13 08:00 | 2002-02-13 17:00 | 57 | 0d |  | ST/HM | 8h |
| 59 | 1.3.3 | Décâblage du reseau 400V | 0.5d | 2002-02-14 08:00 | 2002-02-14 12:00 | 58 | 0d |  | P0/Reg2 | 4h |
| 60 | 1.3.4 | Décâblage des cables contrôle | 0.5d | 2002-02-14 13:00 | 2002-02-14 17:00 | 59 | 0d |  | P0/Reg2 | 4h |
| 61 | 1.3.5 | Démontage des châssis contrôle | 0.5d | 2002-02-15 08:00 | 2002-02-15 12:00 | 60 | 0d |  | P0/Reg2 | 4h |
| 62 | 1.3.6 | Aménagement des racks | 2d | 2002-02-15 13:00 | 2002-02-19 12:00 | 61 | 0d |  | P0/Reg2 | 16h |
| 63 | 1.3.7 | Modification des alimentations Fug | 3d | 2002-02-15 13:00 | 2002-02-20 12:00 | 61 | 19.5d |  | J.P-L./G.S. | 24h |
| 64 | 1.3.8 | Installation des châssis de distribution 400v | 0.5d | 2002-02-19 13:00 | 2002-02-19 17:00 | 62 | 0d |  | P0/Reg2 | 4h |
| 65 | 1.3.9 | Installation des alimentations 500 et 1000A | 5d | 2002-02-20 08:00 | 2002-02-26 17:00 | 64 | 0d |  | P0/Reg2 | 40h |
| 66 | 1.3.10 | Installation des châssis contrôle | 1d | 2002-02-27 08:00 | 2002-02-27 17:00 | 65 | 0d |  | P0/Reg2 | 8h |
| 67 | 1.3.11 | Câblage puissance | 2d | 2002-02-28 08:00 | 2002-03-01 17:00 | 66 | 0d |  | P0/Reg2 | 16h |
| 68 | 1.3.12 | Câblage 220V | 2d | 2002-03-04 08:00 | 2002-03-05 17:00 | 67 | 0d |  | P0/Reg2 | 16h |
| 69 | 1.3.13 | Câblage 400v | 2d | 2002-02-14 08:00 | 2002-02-15 17:00 | 53 | 17d | 0d | ST/EL | 16h |
| 70 | 1.3.14 | Câblage contrôle et interlocks | 5d | 2002-02-18 08:00 | 2002-02-22 17:00 | 69 | 17d |  | ST/EL | 40h |
| 71 | 1.3.15 | Tests | 10d | 2002-03-06 08:00 | 2002-03-19 17:00 | 68 | 0d |  | PS/PO PS/CO | 80h |

| ID | WBS | Task | Duration | Start | Finish | Predecessors | Total slack | Free slack | Resources | Work |
| --- | --- | --- | --- | --- | --- | --- | --- | --- | --- | --- |
| 73 | 1.4 | **Alimentations "SEPARATOR"** | 13d | 2002-01-07 08:00 | 2002-01-23 17:00 |  | 39d |  |  | 104h |
| 74 | 1.4.1 | Usinage des hauts de racks | 3d | 2002-01-07 08:00 | 2002-01-09 17:00 |  | 39d | 0d | PO/SC | 24h |
| 75 | 1.4.2 | Montage des extensions de racks | 2d | 2002-01-10 08:00 | 2002-01-11 17:00 | 74 | 39d | 0d | PS/Reg3 | 16h |
| 76 | 1.4.3 | Câblage interne | 2d | 2002-01-14 08:00 | 2002-01-15 17:00 | 75 | 39d | 0d | PS/Reg3 | 16h |
| 77 | 1.4.4 | Tests | 6d | 2002-01-16 08:00 | 2002-01-23 17:00 | 76 | 39d |  | PS/PO PS/CO | 48h |
